# Aktivitetslista från BORO

Schedule from MS Project, 2006-03-20 to 2007-02-26.

## Calendars

- Standard: Mon-Fri 08:00-12:00, 13:00-17:00; Sat-Sun off.

## Resources

| Resource |
| --- |
| Pia Ledin |
| Övriga |
| Ygnve Stöd |
| Ivan Moreno |
| Fredrik Jansson |
| Eva Johansson |
| Emma Fribergh |
| Sofia Appelgren |
| Tessie Johansson |
| Elin Ek |
| Lennart Lager |
| Finn Slettenberg |
| Sven Hård |
| Nätverkskonsult |
| Severkonsult |
| My Komlin |
| Karri Driftunen |
| Manuel Gonzalez |
| Alf Alvarsson |
| Heinz Platser |
| Mona Lehrer |
| Yngve Stöd |
| utbildningskonsult |

## Schedule

| ID | WBS | Task | Type | Duration | Start | Finish | Predecessors | Total slack | Free slack | Constraint | Resources | Work |
| --- | --- | --- | --- | --- | --- | --- | --- | --- | --- | --- | --- | --- |
| 1 | 1 | Projektuppstart |  | 5d | 2006-03-20 | 2006-03-24 |  | 3d | 0d |  | Pia Ledin; Övriga | 80h |
| 2 | 2 | E-handelssite |  | 2d | 2006-03-27 | 2006-03-28 | 1 | 3d |  |  | Ygnve Stöd; Pia Ledin | 32h |
| 3 | 3 | Webb-site |  | 180d | 2006-03-29 | 2006-12-05 | 2 | 3d |  | finish no earlier than 2006-11-30 | Pia Ledin | 1440h |
| 4 | 4 | Kravspec verktyg |  | 5d | 2006-03-29 | 2006-04-04 |  | 197d | 0d | start no earlier than 2006-03-29 | Ygnve Stöd; Ivan Moreno [90%] | 76h |
| 5 | 5 | Verktyg |  | 7d | 2006-04-05 | 2006-04-13 | 4 | 172d | 0d | start no earlier than 2006-03-29 | Fredrik Jansson; Eva Johansson | 112h |
| 6 | 6 | Inköp |  | 2d | 2006-04-14 | 2006-04-17 | 5 | 197d | 0d | start no earlier than 2006-04-14 | Fredrik Jansson | 16h |
| 8 | 7 | Utveckling |  | 25d | 2006-04-21 | 2006-05-25 |  | 172d |  |  | Ygnve Stöd; Emma Fribergh; Fredrik Jansson [80%]; Ivan Moreno | 760h |
| 9 | 8 | Struktur Site |  | 3d | 2006-04-21 | 2006-04-25 |  | 114.5d | 0d | start no earlier than 2006-04-21 |  |  |
| 10 | 9 | Menyer |  | 5d | 2006-04-26 | 2006-05-02 | 9 | 89.5d | 0d |  | Emma Fribergh; Eva Johansson | 80h |
| 11 | 10 | Mall för varupresentation |  | 5d | 2006-05-03 | 2006-05-09 | 10 | 89.5d | 0d |  | Fredrik Jansson | 40h |
| 12 | 11 | Recceptlåda |  | 4.5d | 2006-05-10 | 2006-05-16 | 11 | 89.5d | 0d |  | Eva Johansson | 36h |
| 13 | 12 | Betalningsfunktion |  | 10d | 2006-05-16 | 2006-05-30 | 12 | 89.5d | 0.5d |  | Ivan Moreno | 80h |
| 14 | 13 | Integrationer |  | 50d | 2006-05-31 | 2006-08-08 | 13 | 114d | 0d | start no earlier than 2006-05-31 | Fredrik Jansson; Ivan Moreno; Ygnve Stöd [50%] | 1000h |
| 15 | 14 | Affärssystem |  | 10d | 2006-08-09 | 2006-08-22 | 14 | 89d | 0d |  | Fredrik Jansson; Ivan Moreno | 160h |
| 16 | 15 | Banker |  | 10d | 2006-08-23 | 2006-09-05 | 15 | 89d | 0d |  | Emma Fribergh | 80h |
| 17 | 16 | Kortföretag |  | 10d | 2006-09-06 | 2006-09-19 | 16 | 114d |  | start no earlier than 2006-09-06 | Emma Fribergh | 80h |
| 18 | 17 | Kravspec |  | 15d | 2006-05-01 | 2006-05-19 |  | 176d |  | start no earlier than 2006-05-01 | Pia Ledin; Ygnve Stöd | 240h |
| 19 | 18 | Funktionsutveckling |  | 32d | 2006-05-01 | 2006-06-13 |  | 63d | 0d | start no earlier than 2006-05-01 | Emma Fribergh; Eva Johansson; Fredrik Jansson; Ivan Moreno | 1024h |
| 20 | 19 | Siddesign |  | 15.5d | 2006-06-14 | 2006-07-05 | 19 | 63d | 0d | start no earlier than 2006-04-30 | Emma Fribergh; Eva Johansson | 248h |
| 21 | 20 | Laddning av varukatalog |  | 3d | 2006-07-05 | 2006-07-10 | 20 | 63d | 0d | start no earlier than 2006-05-06 | Eva Johansson | 24h |
| 22 | 21 | Laddning av prislista-konsument |  | 3d | 2006-07-10 | 2006-07-13 | 21 | 63d | 0d |  | Eva Johansson | 24h |
| 23 | 22 | Beställning |  | 5d | 2006-07-13 | 2006-07-20 | 22 | 63d | 0d |  | Emma Fribergh; Ivan Moreno | 80h |
| 24 | 23 | Betalning |  | 5d | 2006-07-20 | 2006-07-27 | 23 | 63d | 25.5d | start no earlier than 2006-05-23 | Emma Fribergh; Ivan Moreno | 80h |
| 25 | 24 | Test |  | 21d | 2006-08-01 | 2006-08-29 | 24 | 67d | 2d | start no earlier than 2006-08-01 | Ivan Moreno; Ygnve Stöd; Pia Ledin [50%] | 420h |
| 26 | 25 | Produktionstest |  | 16d | 2006-09-01 | 2006-09-22 | 25 | 65d | 0d | start no earlier than 2006-09-01 | Fredrik Jansson; Ivan Moreno | 256h |
| 27 | 26 | Integration |  | 25d | 2006-09-25 | 2006-10-27 | 26 | 40d | 2d | start no earlier than 2006-09-01 | Emma Fribergh; Eva Johansson; Fredrik Jansson; Ivan Moreno | 800h |
| 28 | 27 | Driftsättning |  | 21d | 2006-11-01 | 2006-11-29 | 27 | 63d | 0d | finish no earlier than 2006-11-29 | Ivan Moreno; Emma Fribergh; Eva Johansson; Fredrik Jansson; Ygnve Stöd | 840h |
| 29 | 28 | Klart för kundbeställning | milestone | 0d | 2006-11-30 | 2006-11-30 | 28 | 63d |  | start no earlier than 2006-11-30 | Pia Ledin; Ygnve Stöd |  |
| 30 | 29 | Affärssystem |  | 154d | 2006-03-27 | 2006-10-26 |  | 62d |  | start no earlier than 2006-03-27 | Sofia Appelgren | 1232h |
| 31 | 30 | Kravspecifikation |  | 28d | 2006-03-27 | 2006-05-03 |  | 120.5d | 0d | start no earlier than 2006-03-27 | Tessie Johansson; Elin Ek | 448h |
| 32 | 31 | Skall / Bör krav |  | 10d | 2006-05-04 | 2006-05-17 | 31 | 120.5d | 0d |  | Lennart Lager; Finn Slettenberg | 160h |
| 33 | 32 | Utvärdersmall |  | 3d | 2006-05-18 | 2006-05-22 | 32 | 120.5d | 0d |  | Tessie Johansson | 24h |
| 34 | 33 | Utvärdering |  | 12d | 2006-05-23 | 2006-06-07 | 33 | 120.5d | 0d |  | Tessie Johansson; Finn Slettenberg; Lennart Lager | 288h |
| 35 | 34 | Upphandling |  | 42.5d | 2006-06-08 | 2006-08-07 | 34 | 120.5d |  |  | Elin Ek; Lennart Lager | 680h |
| 36 | 35 | Upphandlingsunderlag |  | 23.5d | 2006-06-01 | 2006-07-04 |  | 71d | 0d | start no earlier than 2006-06-01 | Finn Slettenberg | 188h |
| 37 | 36 | Utskick av förfrågningsunderlag |  | 6d | 2006-07-04 | 2006-07-12 | 36 | 45.5d | 0d | start no earlier than 2006-06-22 | Tessie Johansson | 48h |
| 38 | 37 | Val av leverantör |  | 13d | 2006-07-12 | 2006-07-31 | 37 | 45.5d | 0d | start no earlier than 2006-06-30 | Pia Ledin [50%]; Finn Slettenberg; Lennart Lager | 260h |
| 39 | 38 | Införande |  | 79.5d | 2006-07-31 | 2006-11-17 | 38 | 46d |  | start no earlier than 2006-07-31 | Finn Slettenberg; Elin Ek; Tessie Johansson | 1908h |
| 40 | 39 | Tekniska installationer |  | 5d | 2006-08-01 | 2006-08-07 |  | 70d | 0d | start no earlier than 2006-08-01 | Finn Slettenberg | 40h |
| 41 | 40 | Systeminställningar |  | 10d | 2006-08-08 | 2006-08-21 | 40 | 45d | 0d |  | Finn Slettenberg | 80h |
| 42 | 41 | Systemtester |  | 10d | 2006-08-22 | 2006-09-04 | 41 | 45d | 0d |  | Finn Slettenberg; Lennart Lager | 160h |
| 43 | 42 | Integrationstester |  | 4d | 2006-09-05 | 2006-09-08 | 42 | 45d | 0d |  | Ivan Moreno [50%]; Finn Slettenberg; Lennart Lager | 80h |
| 44 | 43 | Webbeställning |  | 20d | 2006-09-11 | 2006-10-06 | 43 | 45d | 0d |  | Ivan Moreno [50%]; Finn Slettenberg | 160h |
| 45 | 44 | GECAB |  | 10d | 2006-10-09 | 2006-10-20 | 44 | 45d | 0d | start no earlier than 2006-05-28 | Finn Slettenberg; Lennart Lager | 160h |
| 46 | 45 | Acceptanstest |  | 10d | 2006-10-23 | 2006-11-03 | 45 | 45d | 0d | start no earlier than 2006-06-09 | Tessie Johansson | 80h |
| 47 | 46 | Leveransgodkännande |  | 10d | 2006-11-06 | 2006-11-17 | 46 | 45d | 0d | start no earlier than 2006-06-24 | Sofia Appelgren; Finn Slettenberg; Elin Ek; Tessie Johansson | 320h |
| 48 | 47 | Systemaccept |  | 1d | 2006-11-20 | 2006-11-20 | 47 | 45d |  | start no earlier than 2006-09-16 | Pia Ledin; Sofia Appelgren | 16h |
| 49 | 48 | Infrastruktur |  | 42d | 2006-03-20 | 2006-05-16 |  | 121d | 0d |  | Sven Hård | 336h |
| 50 | 49 | Specifikationer |  | 15d | 2006-05-17 | 2006-06-06 | 49 | 121d | 0d |  | Sven Hård; Nätverkskonsult [50%]; Severkonsult [50%]; My Komlin; Karri Driftunen | 480h |
| 51 | 50 | Kravspec maskinvara |  | 5d | 2006-06-07 | 2006-06-13 | 50 | 121d | 0d |  | Karri Driftunen; Severkonsult [50%] | 60h |
| 52 | 51 | Kravspec LAN |  | 5d | 2006-06-14 | 2006-06-20 | 51 | 121d | 0d |  | Karri Driftunen; Nätverkskonsult [50%] | 60h |
| 53 | 52 | Kravspec WAN |  | 5d | 2006-06-21 | 2006-06-27 | 52 | 121d | 0d |  | Karri Driftunen; Nätverkskonsult [50%] | 60h |
| 54 | 53 | Inköp |  | 5d | 2006-06-28 | 2006-07-04 | 53 | 146d | 0d | start no earlier than 2006-06-28 | My Komlin | 40h |
| 55 | 54 | Installationer |  | 23d | 2006-07-05 | 2006-08-04 | 54 | 121d |  |  | Sven Hård | 184h |
| 56 | 55 | Datorrum |  | 15d | 2006-07-05 | 2006-07-25 |  | 122d | 1d | start no earlier than 2006-07-05 | My Komlin; Karri Driftunen | 240h |
| 57 | 56 | Kabeldragning |  | 3d | 2006-07-27 | 2006-07-31 | 56 | 121d | 0d | start no earlier than 2006-07-27 | My Komlin; Karri Driftunen; Nätverkskonsult [30%] | 55.2h |
| 58 | 57 | Anslutning WAN |  | 1d | 2006-08-01 | 2006-08-01 | 57 | 121d | 0d | start no earlier than 2006-08-01 | Nätverkskonsult | 8h |
| 59 | 58 | Operativsystem o säkerhet |  | 2d | 2006-08-02 | 2006-08-03 | 58 | 96d | 0d |  | My Komlin; Severkonsult; Karri Driftunen | 48h |
| 60 | 59 | Ingångkörning |  | 5d | 2006-08-04 | 2006-08-10 | 59 | 96d | 0d |  | My Komlin; Karri Driftunen; Nätverkskonsult; Severkonsult | 160h |
| 61 | 60 | Test |  | 21d | 2006-08-11 | 2006-09-08 | 60 | 121d | 0d | start no earlier than 2006-08-11 | My Komlin; Karri Driftunen; Severkonsult [20%]; Nätverkskonsult [20%] | 403.2h |
| 62 | 61 | Leveransgodkännande | milestone | 0d | 2006-09-08 | 2006-09-08 | 61 | 96d |  |  | Sven Hård |  |
| 63 | 62 | Arbetsprocesser o Utbildning |  | 190d | 2006-03-20 | 2006-12-08 |  | 9d | 0d |  | Manuel Gonzalez | 1520h |
| 64 | 63 | Kartlägga processer |  | 38d | 2006-03-20 | 2006-05-10 |  | 117d | 0d |  | Heinz Platser; utbildningskonsult [50%]; Mona Lehrer | 760h |
| 65 | 64 | Kundbeställning |  | 5d | 2006-05-11 | 2006-05-17 | 64 | 203d |  |  | Heinz Platser | 40h |
| 66 | 65 | Betalning |  | 5d | 2006-05-11 | 2006-05-17 | 64 | 117d | 0d |  | Mona Lehrer; Heinz Platser | 80h |
| 67 | 66 | Orderprocess |  | 5d | 2006-05-18 | 2006-05-24 | 66 | 117d | 0d |  | Mona Lehrer; Heinz Platser | 80h |
| 68 | 67 | Plockning |  | 5d | 2006-05-25 | 2006-05-31 | 67 | 117d | 0d |  | Heinz Platser | 40h |
| 69 | 68 | Packning |  | 5d | 2006-06-01 | 2006-06-07 | 68 | 117d | 0d |  | Mona Lehrer | 40h |
| 70 | 69 | Kundleverans |  | 5d | 2006-06-08 | 2006-06-14 | 69 | 117d | 0d |  | Heinz Platser | 40h |
| 71 | 70 | Utbildning |  | 9d | 2006-06-15 | 2006-06-27 | 70 | 117d | 0d |  | utbildningskonsult [75%]; Mona Lehrer [75%]; Heinz Platser [75%]; Manuel Gonzalez [75%] | 216h |

Notes:
- 1: Gå igenom hela projektet lösa oklarheter ha någon form av kick off så projektmedlemmarna lär känna varandra.
- 2: Gå igenom vad man tänkt med e-handelssiten.
- 3: Övervaka hela delen.
- 8: Utveckling av själva grundplattformen såsom databas design, kopplingar. Skilt från övriga då det skapas som funktioner.
- 18: Gå igenom de funktioner som gjorts och vad som är kvar.
- 23: Beställningsfunktion i e-handelssiten. Är under funktionsutvecklingen
- 27: Brukar vara det som tar längst tid att integrera med affärssystemet och även att alla installationer är färdiga och korrekt utförda.
- 30: Affärssystems upphandlingen.
- 31: kravspec på affärssystemet.
- 43: integration med e-systemet.
- 49: Brukar börja när projektet startas då operativsystem, LAN WAN beskrivningar brukar vara ganska generella.
- 50: Behöver ha in extern kunskap om främst Nätverksbiten men även för operativinstallationen då det är många servrar som ska hålla dessa system.
- 54: Måste göras efter specifikationer på maskinvara LAN och WAN
- 55: Övervakas av projektledaren.
- 56: val av serverum.
- 61: Sträcker sig längre beroende att testerna måste samköras med e-handelssite och även affärssystemet. Konsulterna är med till20% med ev mer om saker strular.
- 63: Pågår under hela projektet och sträcker sig över e-handelssite,affärssystem och infra.
- 64: Behövs en kunnig utbildningskonsult på denna för att stödja processerna.

| ID | WBS | Task | Type | Duration | Start | Finish | Predecessors | Total slack | Free slack | Constraint | Resources | Work |
| --- | --- | --- | --- | --- | --- | --- | --- | --- | --- | --- | --- | --- |
| 72 | 71 | Egen personal |  | 5d | 2006-06-28 | 2006-07-04 | 71 | 117d | 0d |  | utbildningskonsult | 40h |
| 73 | 72 | Plockpersonal |  | 2d | 2006-07-05 | 2006-07-06 | 72 | 117d | 0d |  | Mona Lehrer | 16h |
| 74 | 73 | Speditörer |  | 2d | 2006-07-07 | 2006-07-10 | 73 | 117d | 0d |  | Heinz Platser | 16h |
| 75 | 74 | Retur och reklamation |  | 3d | 2006-07-11 | 2006-07-13 | 74 | 117d | 0d | start no earlier than 2006-05-08 | Heinz Platser | 24h |
| 76 | 75 | Kundreskontra |  | 5d | 2006-07-14 | 2006-07-20 | 75 | 117d | 15d | start no earlier than 2006-05-12 | Heinz Platser | 40h |
| 77 | 76 | Produktionstest |  | 20d | 2006-08-11 | 2006-09-07 | 76 | 102d | 0d | start no earlier than 2006-08-11 | Manuel Gonzalez; utbildningskonsult [50%] | 240h |
| 78 | 77 | Beställning-betalning |  | 10d | 2006-09-08 | 2006-09-21 | 77 | 102d | 0d |  | Heinz Platser; Mona Lehrer | 160h |
| 79 | 78 | Plockning -leverans |  | 10d | 2006-09-22 | 2006-10-05 | 78 | 102d |  |  | Heinz Platser; Mona Lehrer | 160h |
| 80 | 79 | KLART FÖR LANCERING | milestone | 0d | 2006-12-08 | 2006-12-08 | 63 | 9d | 0d | start no earlier than 2006-10-07 | Sven Hård; Pia Ledin; Yngve Stöd; Sofia Appelgren |  |
| 81 | 80 | Produktion |  | 45d | 2006-12-11 | 2007-02-09 | 80 | 11d |  | start no earlier than 2006-12-09 | Manuel Gonzalez; Ivan Moreno; Fredrik Jansson; Lennart Lager | 1440h |
| 82 | 81 | Stöd av produktion |  | 45d | 2006-12-11 | 2007-02-09 | 80 | 9d | 0d | start no earlier than 2006-12-10 | Eva Johansson; Lennart Lager | 720h |
| 83 | 82 | Förvaltningsorgaisation |  | 33d | 2006-12-11 | 2007-01-24 |  | 0d |  | start no earlier than 2006-12-11 | Manuel Gonzalez; Sven Hård | 528h |
| 84 | 83 | Ta fram förvaltningsplan |  | 10d | 2007-01-25 | 2007-02-07 | 83 | 0d |  |  | Sven Hård; Pia Ledin | 160h |
| 85 | 84 | Bestäm förvaltningsobjekt |  | 5d | 2007-02-08 | 2007-02-14 | 84 | 0d |  | start no earlier than 2006-05-02 | Manuel Gonzalez; Sven Hård | 80h |
| 86 | 85 | Fastställ förvaltnings processer |  | 3d | 2007-02-15 | 2007-02-19 | 85 | 0d |  |  | Manuel Gonzalez; Sven Hård | 48h |
| 87 | 86 | Bemanna |  | 2d | 2007-02-20 | 2007-02-21 | 86 | 0d |  | start no earlier than 2007-02-05 | Manuel Gonzalez; Sven Hård | 32h |
| 88 | 87 | Överlämnade till förvaltning |  | 3d | 2007-02-22 | 2007-02-26 | 87 | 0d |  | start no earlier than 2007-02-07 | Pia Ledin; Manuel Gonzalez; Sven Hård | 72h |
| 89 | 88 | Godkännande av projektresultat |  | 1d | 2007-02-12 | 2007-02-12 | 82 | 9d | 0d | start no earlier than 2007-02-12 | Pia Ledin | 8h |
| 90 | 89 | Projektavslut |  | 1d | 2007-02-13 | 2007-02-13 | 89 | 9d |  | start no earlier than 2007-02-12 | Pia Ledin; Alf Alvarsson | 16h |

Notes:
- 77: Måste göras i samband att infrastruktur affärssystem & e handelsite är klar. Krävs synkning mellan projektledarna.
- 81: Viktiga resurser från varje delprojekt är med och stödjer produktionen.
- 82: Viktiga resurser från varje delprojekt är med.
- 83: Förvaltningsorganisationen eller driftsavdelningen har sista godkännandet att man fått tillräckligt med dokumentation, stöd, utbildning, etc av projektet för att kunna köra det i skarp produktion utan hjälp från projektet.
- 88: överlämningsmöte att man fått med all överlämnande till förvaltningen.
