# Aktivitetslista 2006-03-05

Schedule from MS Project, 2006-01-02 to 2007-03-06, costs in kr.

## Calendars

- Standard: Mon-Fri 08:00-12:00, 13:00-17:00; Sat-Sun off.

## Resources

| Resource | Rate |
| --- | --- |
| Yngve Stöd | 300 |
| Iván Moreno | 300 |
| Fredrik Jansson | 300 |
| Emma Fribergh | 300 |
| Eva Johansson | 300 |
| Sofia Appelgren | 300 |
| Tessie Johansson | 300 |
| Elin Ek | 300 |
| Lennart Lager | 300 |
| Finn Slettenberg | 300 |
| Sven Hård | 300 |
| My Komlin | 300 |
| Karri Driftunen | 300 |
| Manuel Gonzales | 300 |
| Heinz Platser | 300 |
| Mona Lehrer | 300 |
| Per Ledman | 300 |

## Schedule

| ID | WBS | Task | Duration | Start | Finish | Predecessors | Total slack | Free slack | Constraint | Deadline | Resources | Work | Cost |
| --- | --- | --- | --- | --- | --- | --- | --- | --- | --- | --- | --- | --- | --- |
| 1 | 1 | GOL-IT | 1d? | 2006-01-02 | 2006-01-02 |  | 306d |  |  |  |  |  |  |
| 2 | 2 | Projektuppstart | 1d? | 2006-02-06 | 2006-02-06 |  | 80d | 0d | start no earlier than 2006-02-06 |  |  |  |  |
| 3 | 3 | Projektledningsmöte | 0.5d | 2006-01-02 | 2006-01-02 |  | 306.5d |  |  |  |  |  |  |
| 4 | 4 | Riskanalys 1 | 2d | 2006-03-31 | 2006-04-03 | 76 | 241d |  |  |  |  |  |  |
| 5 | 5 | Riskanalys 2 | 2d | 2006-10-03 | 2006-10-04 |  | 0d |  | start no earlier than 2006-10-03 | 2006-10-04 |  |  |  |
| 6 | 6 | **E-handelssite** | 281d | 2006-02-07 | 2007-03-06 |  | 0d |  |  |  |  | 2552h | 765,600 |
| 7 | 6.1 | **Verktyg** | 154d | 2006-02-07 | 2006-09-08 |  | 0d |  |  |  |  | 176h | 52,800 |
| 8 | 6.1.1 | Kravspec verktyg | 10d | 2006-02-07 | 2006-02-20 | 2 | 80d | 0d |  |  | Yngve Stöd | 80h | 24,000 |
| 9 | 6.1.2 | Inköp | 10d | 2006-02-21 | 2006-03-06 | 8 | 132d |  |  |  | Yngve Stöd | 80h | 24,000 |
| 10 | 6.1.3 | Installation | 2d | 2006-09-07 | 2006-09-08 | 9, 57 | 0d |  |  |  | Yngve Stöd | 16h | 4,800 |
| 11 | 6.2 | **Struktur Site** | 30d | 2006-09-11 | 2006-10-20 |  | 0d |  |  |  |  | 240h | 72,000 |
| 12 | 6.2.1 | Menyer | 5d | 2006-09-11 | 2006-09-15 | 10 | 0d |  |  |  | Yngve Stöd | 40h | 12,000 |
| 13 | 6.2.2 | Mall för varupresentation | 5d | 2006-09-18 | 2006-09-22 | 12 | 0d |  |  |  | Yngve Stöd | 40h | 12,000 |
| 14 | 6.2.3 | Betalningsfunktion | 10d | 2006-09-25 | 2006-10-06 | 13 | 0d |  |  |  | Yngve Stöd | 80h | 24,000 |
| 15 | 6.2.4 | Recceptlåda | 10d | 2006-10-09 | 2006-10-20 | 14 | 0d |  |  |  | Yngve Stöd | 80h | 24,000 |
| 16 | 6.3 | **Integrationer** | 30d | 2006-11-13 | 2006-12-22 |  | 15d |  |  |  |  | 240h | 72,000 |
| 17 | 6.3.1 | Affärssystem | 10d | 2006-11-13 | 2006-11-24 | 21 | 15d | 0d |  |  | Yngve Stöd | 80h | 24,000 |
| 18 | 6.3.2 | Banker | 10d | 2006-11-27 | 2006-12-08 | 17 | 15d | 0d |  |  | Yngve Stöd | 80h | 24,000 |
| 19 | 6.3.3 | Kortföretag | 10d | 2006-12-11 | 2006-12-22 | 18 | 15d |  |  |  | Yngve Stöd | 80h | 24,000 |
| 20 | 6.4 | **Utveckling** | 70d | 2006-10-23 | 2007-01-26 |  | 0d |  |  |  |  | 1680h | 504,000 |
| 21 | 6.4.1 | Kravspec | 15d | 2006-10-23 | 2006-11-10 | 15 | 0d |  |  |  | Yngve Stöd | 120h | 36,000 |
| 22 | 6.4.2 | Funktionsutveckling | 40d | 2006-11-13 | 2007-01-05 | 21 | 0d |  |  |  | Yngve Stöd [50%]; Iván Moreno; Fredrik Jansson; Eva Johansson; Emma Fribergh | 1440h | 432,000 |
| 23 | 6.4.3 | Siddesign | 5d | 2007-01-08 | 2007-01-12 | 22 | 0d |  |  |  | Yngve Stöd | 40h | 12,000 |
| 24 | 6.4.4 | Test | 10d | 2007-01-15 | 2007-01-26 | 23, 19 | 0d |  |  |  | Yngve Stöd | 80h | 24,000 |

Notes:
- 3: Projektmöte varje måndag kl 13.00 / Plats: Stora konferensrummet

| ID | WBS | Task | Type | Duration | Start | Finish | Predecessors | Total slack | Free slack | Resources | Work | Cost |
| --- | --- | --- | --- | --- | --- | --- | --- | --- | --- | --- | --- | --- |
| 25 | 6.5 | **Driftsättning** |  | 27d | 2007-01-29 | 2007-03-06 |  | 0d |  |  | 216h | 64,800 |
| 26 | 6.5.1 | Laddning av varukatalog |  | 3d | 2007-01-29 | 2007-01-31 | 24 | 0d |  | Yngve Stöd | 24h | 7,200 |
| 27 | 6.5.2 | Laddning av prislista-konsument |  | 3d | 2007-02-01 | 2007-02-05 | 26 | 0d |  | Yngve Stöd | 24h | 7,200 |
| 28 | 6.5.3 | Beställning |  | 5d | 2007-02-06 | 2007-02-12 | 27 | 0d |  | Yngve Stöd | 40h | 12,000 |
| 29 | 6.5.4 | Betalning |  | 5d | 2007-02-13 | 2007-02-19 | 28 | 0d |  | Yngve Stöd | 40h | 12,000 |
| 30 | 6.5.5 | Integration |  | 5d | 2007-02-20 | 2007-02-26 | 29 | 0d |  | Yngve Stöd | 40h | 12,000 |
| 31 | 6.5.6 | Produktionstest |  | 6d | 2007-02-27 | 2007-03-06 | 30 | 0d |  | Yngve Stöd | 48h | 14,400 |
| 32 | 6.5.7 | Klart för kundbeställning | milestone | 0d | 2007-03-06 | 2007-03-06 | 31 | 0d |  | Yngve Stöd |  |  |
| 33 | 7 | **Affärssystem** |  | 159d | 2006-03-31 | 2006-11-08 |  | 84d |  |  | 1016h | 304,800 |
| 34 | 7.1 | **Kravspecifikation** |  | 28d | 2006-03-31 | 2006-05-09 |  | 128d |  |  | 224h | 67,200 |
| 35 | 7.1.1 | Skall / Bör krav |  | 10d | 2006-03-31 | 2006-04-13 | 76 | 128d | 0d | Sofia Appelgren | 80h | 24,000 |
| 36 | 7.1.2 | Utvärdersmall |  | 3d | 2006-04-14 | 2006-04-18 | 35 | 128d | 0d | Sofia Appelgren | 24h | 7,200 |
| 37 | 7.1.3 | Upphandlingsunderlag |  | 15d | 2006-04-19 | 2006-05-09 | 36 | 128d | 0d | Sofia Appelgren | 120h | 36,000 |
| 38 | 7.2 | **Upphandling** |  | 42d | 2006-06-07 | 2006-08-03 |  | 108d |  | Sofia Appelgren | 352h | 105,600 |
| 39 | 7.2.1 | Utskick av förfrågningsunderlag |  | 5d | 2006-06-07 | 2006-06-13 | 37FS+20d | 128d | 0d | Sofia Appelgren | 40h | 12,000 |
| 40 | 7.2.2 | Utvärdering |  | 12d | 2006-06-14 | 2006-06-29 | 39 | 128d | 0d | Sofia Appelgren | 96h | 28,800 |
| 41 | 7.2.3 | Val av leverantör |  | 5d | 2006-06-30 | 2006-08-03 | 40 | 108d | 0d | Sofia Appelgren | 40h | 12,000 |
| 42 | 7.3 | **Införande** |  | 45d | 2006-09-07 | 2006-11-08 |  | 84d |  | Sofia Appelgren | 360h | 108,000 |
| 43 | 7.3.1 | Tekniska installationer |  | 5d | 2006-09-07 | 2006-09-13 | 41, 66 | 84d | 0d | Sofia Appelgren | 40h | 12,000 |
| 44 | 7.3.2 | Systeminställningar |  | 10d | 2006-09-14 | 2006-09-27 | 43 | 84d | 0d | Sofia Appelgren | 80h | 24,000 |
| 45 | 7.3.3 | Systemtester |  | 10d | 2006-09-28 | 2006-10-11 | 44 | 84d | 0d | Sofia Appelgren | 80h | 24,000 |
| 46 | 7.3.4 | **Integrationstester** |  | 20d | 2006-10-12 | 2006-11-08 |  | 84d |  | Sofia Appelgren | 160h | 48,000 |
| 47 | 7.3.4.1 | Webbeställning |  | 10d | 2006-10-12 | 2006-10-25 | 45 | 84d | 0d | Sofia Appelgren | 80h | 24,000 |
| 48 | 7.3.4.2 | GECAB |  | 10d | 2006-10-26 | 2006-11-08 | 47 | 84d |  | Sofia Appelgren | 80h | 24,000 |

| ID | WBS | Task | Type | Duration | Start | Finish | Predecessors | Total slack | Free slack | Constraint | Resources | Work | Cost |
| --- | --- | --- | --- | --- | --- | --- | --- | --- | --- | --- | --- | --- | --- |
| 49 | 7.4 | **Leveransgodkännande** |  | 10d | 2006-10-06 | 2006-10-19 |  | 11d |  |  |  | 80h | 24,000 |
| 50 | 7.4.1 | Acceptanstest |  | 10d | 2006-10-06 | 2006-10-19 | 80 | 11d | 0d |  | Sofia Appelgren | 80h | 24,000 |
| 51 | 7.4.2 | Systemaccept | milestone | 0d | 2006-10-19 | 2006-10-19 | 50 | 11d |  |  | Sofia Appelgren |  |  |
| 52 | 8 | **Infrastruktur** |  | 142d | 2006-02-21 | 2006-09-06 |  | 80d |  |  |  | 1408h | 422,400 |
| 53 | 8.1 | **Specifikationer** |  | 15d | 2006-02-21 | 2006-03-13 |  | 80d |  |  |  | 120h | 36,000 |
| 54 | 8.1.1 | Kravspec maskinvara |  | 5d | 2006-02-21 | 2006-02-27 | 8 | 80d | 0d |  | Sven Hård | 40h | 12,000 |
| 55 | 8.1.2 | Kravspec LAN |  | 5d | 2006-02-28 | 2006-03-06 | 54 | 80d | 0d |  | Sven Hård | 40h | 12,000 |
| 56 | 8.1.3 | Kravspec WAN |  | 5d | 2006-03-07 | 2006-03-13 | 55 | 80d | 0d |  | Sven Hård | 40h | 12,000 |
| 57 | 8.2 | **Inköp** |  | 127d | 2006-03-14 | 2006-09-06 | 56 | 0d |  |  | Sven Hård | 1288h | 386,400 |
| 58 | 8.2.1 | Köp in |  | 5d | 2006-03-14 | 2006-03-20 |  | 100d |  |  |  |  |  |
| 59 | 8.2.2 | **Installationer** |  | 27d | 2006-08-01 | 2006-09-06 |  | 0d |  |  | Sven Hård | 432h | 129,600 |
| 60 | 8.2.2.1 | Datorrum |  | 15d | 2006-08-01 | 2006-08-21 | 54, 58SS | 0d |  | as late as possible | Sven Hård | 120h | 36,000 |
| 61 | 8.2.2.2 | Kabeldragning |  | 3d | 2006-08-22 | 2006-08-24 | 60 | 0d |  |  | Sven Hård | 24h | 7,200 |
| 62 | 8.2.2.3 | Anslutning WAN |  | 1d | 2006-08-25 | 2006-08-25 | 61 | 0d |  |  | Sven Hård | 8h | 2,400 |
| 63 | 8.2.2.4 | Operativsystem o säkerhet |  | 2d | 2006-08-28 | 2006-08-29 | 62 | 0d |  |  | Sven Hård | 16h | 4,800 |
| 64 | 8.2.2.5 | Ingångkörning |  | 5d | 2006-08-30 | 2006-09-05 | 63 | 0d |  |  | Sven Hård | 40h | 12,000 |
| 65 | 8.2.2.6 | Test |  | 1d | 2006-09-06 | 2006-09-06 | 64 | 0d |  |  | Sven Hård | 8h | 2,400 |
| 66 | 8.3 | Leveransgodkännande | milestone | 0d | 2006-09-06 | 2006-09-06 | 65 | 84d | 0d |  | Sven Hård |  |  |
| 67 | 9 | **Arbetsprocesser o Utbildning** |  | 214d | 2006-02-07 | 2006-12-01 |  | 0d |  |  |  | 760h | 228,000 |
| 68 | 9.1 | **Kartlägga processer** |  | 38d | 2006-02-07 | 2006-03-30 |  | 128d |  |  |  | 280h | 84,000 |
| 69 | 9.1.1 | Kundbeställning |  | 5d | 2006-02-07 | 2006-02-13 | 2 | 128d | 0d |  | Manuel Gonzales | 40h | 12,000 |
| 70 | 9.1.2 | Betalning |  | 5d | 2006-02-14 | 2006-02-20 | 69 | 128d | 0d |  | Manuel Gonzales | 40h | 12,000 |
| 71 | 9.1.3 | Orderprocess |  | 5d | 2006-02-21 | 2006-02-27 | 70 | 128d | 0d |  | Manuel Gonzales | 40h | 12,000 |
| 72 | 9.1.4 | Plockning |  | 5d | 2006-02-28 | 2006-03-06 | 71 | 128d | 0d |  | Manuel Gonzales | 40h | 12,000 |
| 73 | 9.1.5 | Packning |  | 5d | 2006-03-07 | 2006-03-13 | 72 | 128d | 0d |  | Manuel Gonzales | 40h | 12,000 |
| 74 | 9.1.6 | Kundleverans |  | 5d | 2006-03-14 | 2006-03-20 | 73 | 128d | 0d |  | Manuel Gonzales | 40h | 12,000 |
| 75 | 9.1.7 | Retur och reklamation |  | 3d | 2006-03-21 | 2006-03-23 | 74 | 128d | 0d |  |  |  |  |
| 76 | 9.1.8 | Kundreskontra |  | 5d | 2006-03-24 | 2006-03-30 | 75 | 128d | 0d |  | Manuel Gonzales | 40h | 12,000 |

| ID | WBS | Task | Type | Duration | Start | Finish | Predecessors | Total slack | Free slack | Constraint | Resources | Work | Cost |
| --- | --- | --- | --- | --- | --- | --- | --- | --- | --- | --- | --- | --- | --- |
| 77 | 9.2 | **Utbildning** |  | 9d | 2006-09-25 | 2006-10-05 |  | 11d |  |  |  | 72h | 21,600 |
| 78 | 9.2.1 | Egen personal |  | 5d | 2006-09-25 | 2006-09-29 |  | 11d | 0d | start no earlier than 2006-09-25 | Mona Lehrer | 40h | 12,000 |
| 79 | 9.2.2 | Plockpersonal |  | 2d | 2006-10-02 | 2006-10-03 | 78 | 11d | 0d |  | Mona Lehrer | 16h | 4,800 |
| 80 | 9.2.3 | Speditörer |  | 2d | 2006-10-04 | 2006-10-05 | 79 | 11d | 0d |  | Mona Lehrer | 16h | 4,800 |
| 81 | 9.3 | **Produktionstest** |  | 31d | 2006-10-20 | 2006-12-01 |  | 0d |  |  | Manuel Gonzales | 408h | 122,400 |
| 82 | 9.3.1 | Beställning-betalning |  | 10d | 2006-10-20 | 2006-11-02 | 51 | 11d | 0d | start no earlier than 2006-10-09 | Manuel Gonzales | 80h | 24,000 |
| 83 | 9.3.2 | Plockning -leverans |  | 10d | 2006-11-03 | 2006-11-16 | 82 | 11d |  |  | Manuel Gonzales | 80h | 24,000 |
| 84 | 9.3.3 | KLART FÖR LANSERING | milestone | 0d | 2006-12-01 | 2006-12-01 | 83 | 0d |  | must finish on 2006-12-01 | Manuel Gonzales |  |  |
| 85 | 10 | **Produktion** |  | 67d | 2006-12-04 | 2007-03-06 |  | 0d |  |  |  |  |  |
| 86 | 10.1 | Stöd av produktion |  | 67d | 2006-12-04 | 2007-03-06 | 84 | 0d |  |  |  |  |  |
| 87 | 11 | **Förvaltningsorgaisation** |  | 22d | 2007-01-29 | 2007-02-27 |  | 5d |  |  |  |  |  |
| 88 | 11.1 | Bestäm förvaltningsobjekt |  | 5d | 2007-01-29 | 2007-02-02 | 84FS+40d | 5d | 0d |  |  |  |  |
| 89 | 11.2 | Fastställ förvaltnings processer |  | 5d | 2007-02-05 | 2007-02-09 | 88 | 5d | 0d |  |  |  |  |
| 90 | 11.3 | Bemanna |  | 2d | 2007-02-12 | 2007-02-13 | 89 | 5d | 0d |  |  |  |  |
| 91 | 11.4 | Ta fram förvaltningsplan |  | 10d | 2007-02-14 | 2007-02-27 | 90 | 5d |  |  |  |  |  |
| 92 | 12 | **Projektavslut** |  | 0d | 2007-03-06 | 2007-03-06 |  | 0d |  |  |  |  |  |
| 93 | 12.1 | Godkännande av projektresultat | milestone | 0d | 2007-03-06 | 2007-03-06 | 86 | 0d |  |  |  |  |  |
| 94 | 12.2 | Överlämnade till förvaltning | milestone | 0d | 2007-03-06 | 2007-03-06 | 93, 91 | 0d |  |  |  |  |  |
